# 01 Cronograma MARS - Área Tanque rev01

Schedule from MS Project, 2018-07-23 to 2018-12-13.

## Calendars

- Calendário BID 2017/2019: Mon-Fri 08:00-12:00, 13:00-17:00; Sat-Sun off. Exceptions (off unless hours are given): 2018-09-07 (Independencia Rep.), 2018-10-12 (Nossa Senhora Apar.), 2018-11-02 (Finados), 2018-11-15 (Proclamação Repulbica), 2018-11-26 (Natal - 18).

## Resources

| Resource |
| --- |
| Ajudante |
| Pedreiro |
| Carpinteiro |
| Armador |
| Eletricista |
| Bombeiro Hidráulico |
| Escavadeira |
| Terceiro Asfalto |
| Bloqueiros |
| Terceiro Sinalização |
| Retroescavadeira |
| Terceiro Paisagismo |
| Helice Continua |
| Munck |
| Terceiro Pre Moldado |
| Munk |
| Plataforma |
| Terceiro Cobertura |
| Rolo compactador |
| Moto Niveladora |
| Terceiro Piso |
| Terceiro Instalações |
| Pintor |
| 137 |

## Schedule

| ID | WBS | Task | Type | Duration | Start | Finish | Predecessors | Baseline start | Baseline finish | Baseline duration | Baseline 1 start | Baseline 1 finish | Total slack | Free slack | Constraint |
| --- | --- | --- | --- | --- | --- | --- | --- | --- | --- | --- | --- | --- | --- | --- | --- |
| 1 | 1 | **CRONOGRAMA FÍSICO - OBRA INDUSTRIAL** |  | 99d | 2018-07-23 | 2018-12-13 |  | 2018-07-23 | 2018-10-23 | 65d | 2018-07-23 | 2018-11-06 | 0d |  |  |
| 2 | 1.1 | **MOBILIZAÇÃO** |  | 37d | 2018-07-23 | 2018-09-12 |  | 2018-07-23 | 2018-08-01 | 8d | 2018-07-23 | 2018-08-03 | 0d |  |  |
| 3 | 1.1.1 | Ajustes de canteiro |  | 7d | 2018-09-03 | 2018-09-12 |  | 2018-07-23 | 2018-07-31 | 7d | 2018-07-23 | 2018-07-31 | 0d |  | start no earlier than 2018-09-03 |
| 4 | 1.1.2 | Liberação da área para início dos serviços |  | 10d | 2018-07-23 | 2018-08-03 |  | 2018-07-23 | 2018-08-01 | 8d | 2018-07-23 | 2018-08-03 | 22d | 0d |  |
| 5 | 1.2 | **ÁREA DE TANQUES** |  | 37d | 2018-08-08 | 2018-09-29 |  | 2018-08-02 | 2018-09-08 | 26d | 2018-08-08 | 2018-09-24 | 22d |  |  |
| 6 | 1.2.1 | Execução do aterro da área para acesso do equipamento |  | 3d | 2018-08-08 | 2018-08-10 | 4FS+2d | 2018-08-02 | 2018-08-03 | 2d | 2018-08-08 | 2018-08-10 | 22d | 0d |  |
| 7 | 1.2.2 | **MURO DE ARRIMO** |  | 34d | 2018-08-08 | 2018-09-25 |  | 2018-08-06 | 2018-09-05 | 23d | 2018-08-08 | 2018-09-18 | 22d |  |  |
| 8 | 1.2.2.1 | Corte do talude (espaçamento míinimo entre o tanque e o muro) |  | 3d | 2018-08-08 | 2018-08-10 | 6FF |  |  |  | 2018-08-08 | 2018-08-10 | 22d | 0d |  |
| 9 | 1.2.2.2 | Execução das estacas do muro de arrimo |  | 13d | 2018-08-13 | 2018-08-29 | 6, 8 | 2018-08-06 | 2018-08-16 | 9d | 2018-08-13 | 2018-08-27 | 22d | 0d |  |
| 10 | 1.2.2.3 | Arrasamento das estacas |  | 12d | 2018-08-16 | 2018-08-31 | 9SS+3d | 2018-08-08 | 2018-08-17 | 8d | 2018-08-14 | 2018-08-29 | 22d | 0d |  |
| 11 | 1.2.2.4 | Escavação das sapatas |  | 12d | 2018-08-17 | 2018-09-03 | 10SS+1d | 2018-08-09 | 2018-08-20 | 8d | 2018-08-15 | 2018-09-04 | 30d | 0d |  |
| 12 | 1.2.2.5 | Forma e armação das sapatas |  | 12d | 2018-08-17 | 2018-09-03 | 10SS+1d | 2018-08-13 | 2018-08-22 | 8d | 2018-08-15 | 2018-09-04 | 63d |  |  |
| 13 | 1.2.2.6 | Concretagem das sapatas |  | 12d | 2018-08-17 | 2018-09-03 | 10SS+1d | 2018-08-23 | 2018-08-23 | 1d | 2018-08-15 | 2018-09-04 | 22d | 0d |  |
| 14 | 1.2.2.7 | Execução do muro de arrimo interno |  | 12d | 2018-08-28 | 2018-09-13 | 13FS-5d | 2018-08-24 | 2018-08-29 | 4d | 2018-08-29 | 2018-09-10 | 22d | 0d |  |
| 15 | 1.2.2.8 | Execução do muro de arrimo até altura de 4m (incluindo drenagem) |  | 8d | 2018-09-14 | 2018-09-25 | 14 | 2018-08-30 | 2018-09-05 | 5d | 2018-09-11 | 2018-09-18 | 22d | 0d |  |
| 16 | 1.2.3 | **PISO - ÁREA DOS TANQUES** |  | 21d | 2018-08-30 | 2018-09-29 |  | 2018-08-17 | 2018-09-08 | 15d | 2018-08-28 | 2018-09-24 | 40d |  |  |
| 17 | 1.2.3.1 | Ajuste no talude + reaterro |  | 3d | 2018-08-30 | 2018-09-03 | 4, 9 | 2018-08-17 | 2018-08-20 | 2d | 2018-08-28 | 2018-08-30 | 40d | 0d |  |
| 18 | 1.2.3.2 | Preparação da base |  | 6d | 2018-08-31 | 2018-09-10 | 17SS+1d | 2018-08-21 | 2018-08-27 | 5d | 2018-08-29 | 2018-09-05 | 40d | 0d |  |
| 19 | 1.2.3.3 | Execução de infra enterradas |  | 2d | 2018-09-06 | 2018-09-10 | 18FF | 2018-08-24 | 2018-08-27 | 2d | 2018-09-04 | 2018-09-05 | 40d | 0d |  |
| 20 | 1.2.3.4 | **CONCRETAGEM PISO - ETAPA 1** |  | 16d | 2018-09-05 | 2018-09-27 |  |  |  |  | 2018-09-03 | 2018-09-22 | 40d |  |  |
| 21 | 1.2.3.4.1 | Forma perimetral |  | 3d | 2018-09-05 | 2018-09-10 | 19FF, 26FF, 30FF | 2018-08-27 | 2018-08-27 | 1d | 2018-09-03 | 2018-09-05 | 40d | 3d |  |
| 22 | 1.2.3.4.2 | Assentamento das tubulações enterradas |  | 2d | 2018-09-06 | 2018-09-10 | 18FF |  |  |  | 2018-09-04 | 2018-09-05 | 59d |  |  |
| 23 | 1.2.3.4.3 | Instalação da grelha |  | 2d | 2018-09-06 | 2018-09-10 | 18FF |  |  |  | 2018-09-04 | 2018-09-05 | 59d |  |  |
| 24 | 1.2.3.4.4 | Armação e concretagem do piso |  | 2d | 2018-09-14 | 2018-09-17 | 21, 14 | 2018-08-28 | 2018-08-29 | 2d | 2018-09-11 | 2018-09-12 | 37d | 0d |  |
| 25 | 1.2.3.4.5 | Liberação da área para acesso de equipamentos (EVENTO) | milestone | 0d | 2018-09-27 | 2018-09-27 | 24FS+10ed | 2018-09-08 | 2018-09-08 |  | 2018-09-22 | 2018-09-22 | 46d |  |  |
| 26 | 1.2.3.4.6 | Execução de infra enterrada |  | 2d | 2018-09-06 | 2018-09-10 | 18FF | 2018-08-24 | 2018-08-27 | 2d | 2018-09-04 | 2018-09-05 | 40d | 0d |  |

| ID | WBS | Task | Type | Duration | Start | Finish | Predecessors | Baseline start | Baseline finish | Baseline duration | Baseline 1 start | Baseline 1 finish | Total slack | Free slack | Constraint |
| --- | --- | --- | --- | --- | --- | --- | --- | --- | --- | --- | --- | --- | --- | --- | --- |
| 27 | 1.2.3.5 | **CONCRETAGEM PISO - ETAPA 2** |  | 16d | 2018-09-06 | 2018-09-29 |  |  |  |  | 2018-09-04 | 2018-09-24 | 40d |  |  |
| 28 | 1.2.3.5.1 | Forma perimetral |  | 1d | 2018-09-10 | 2018-09-10 | 19FF, 26FF, 30FF | 2018-08-27 | 2018-08-27 | 1d | 2018-09-05 | 2018-09-05 | 42d | 5d |  |
| 29 | 1.2.3.5.2 | Assentamento das tubulações enterradas |  | 2d | 2018-09-06 | 2018-09-10 | 18FF |  |  |  | 2018-09-04 | 2018-09-05 | 59d |  |  |
| 30 | 1.2.3.5.3 | Execução das infra enterradas |  | 2d | 2018-09-06 | 2018-09-10 | 18FF | 2018-08-24 | 2018-08-27 | 2d | 2018-09-04 | 2018-09-05 | 40d | 0d |  |
| 31 | 1.2.3.5.4 | Instalação da grelha |  | 2d | 2018-09-06 | 2018-09-10 | 18FF |  |  |  | 2018-09-04 | 2018-09-05 | 59d |  |  |
| 32 | 1.2.3.5.5 | Armação e concretagem do piso |  | 2d | 2018-09-18 | 2018-09-19 | 28, 24 | 2018-08-28 | 2018-08-29 | 2d | 2018-09-13 | 2018-09-14 | 37d | 0d |  |
| 33 | 1.2.3.5.6 | Liberação da área para acesso de equipamentos (EVENTO) | milestone | 0d | 2018-09-29 | 2018-09-29 | 32FS+10ed | 2018-09-08 | 2018-09-08 | 0d | 2018-09-24 | 2018-09-24 | 45d |  |  |
| 34 | 1.3 | **GALPÃO** |  | 50d | 2018-08-20 | 2018-10-30 |  | 2018-08-01 | 2018-10-01 | 43d | 2018-08-08 | 2018-09-24 | 22d |  |  |
| 35 | 1.3.1 | **ESTRUTURA METÁLICA** |  | 10d | 2018-08-20 | 2018-08-31 |  |  |  |  | 2018-08-13 | 2018-08-24 | 32d |  |  |
| 36 | 1.3.1.1 | Moblização Equipe Estrutura Metálica (EVENTO) | milestone | 0d | 2018-08-20 | 2018-08-20 |  |  |  |  | 2018-08-13 | 2018-08-13 | 32d | 0d | start no earlier than 2018-08-20 |
| 37 | 1.3.1.2 | Montagem da estrutura de cobertura |  | 3d | 2018-08-20 | 2018-08-22 | 36 | 2018-08-10 | 2018-08-14 | 3d | 2018-08-13 | 2018-08-15 | 32d | 0d |  |
| 38 | 1.3.1.3 | Montagem das telhas de cobertura - 1ª Camada TELHA |  | 2d | 2018-08-23 | 2018-08-24 | 37 | 2018-08-15 | 2018-08-17 | 3d | 2018-08-16 | 2018-08-17 | 32d | 0d |  |
| 39 | 1.3.1.4 | Montagem das telhas de cobertura - 2ª Camada TELHA |  | 3d | 2018-08-27 | 2018-08-29 | 38 |  |  |  | 2018-08-20 | 2018-08-22 | 33d | 0d |  |
| 40 | 1.3.1.5 | Instalação das linhas de vida na cobertura |  | 2d | 2018-08-30 | 2018-08-31 | 39 | 2018-08-20 | 2018-08-22 | 3d | 2018-08-23 | 2018-08-24 | 39d | 2d |  |
| 41 | 1.3.2 | **FECHAMENTOS** |  | 17d | 2018-09-20 | 2018-10-15 |  |  |  |  | 2018-08-08 | 2018-09-06 | 0d |  |  |
| 42 | 1.3.2.1 | Preparação da área de baldrame |  | 3d | 2018-09-20 | 2018-09-24 | 3FS+5d | 2018-08-01 | 2018-08-03 | 3d | 2018-08-08 | 2018-08-10 | 0d |  |  |
| 43 | 1.3.2.2 | Execução da alvenaria de fechamento perimetral - 1ª etapa |  | 4d | 2018-09-25 | 2018-09-28 | 42, 38 | 2018-08-06 | 2018-08-09 | 4d | 2018-08-20 | 2018-08-23 | 12d | 0d |  |
| 44 | 1.3.2.3 | Execução da alvenaria de fechamento perimetral - 2ª etapa |  | 10d | 2018-10-01 | 2018-10-15 | 43, 38, 39 | 2018-08-20 | 2018-08-31 | 10d | 2018-08-24 | 2018-09-06 | 12d | 0d |  |
| 45 | 1.3.3 | **PISO** |  | 14d | 2018-08-27 | 2018-09-14 |  |  |  |  |  |  | 47d |  |  |
| 46 | 1.3.3.1 | Escavação do fosso e canaleta |  | 3d | 2018-08-27 | 2018-08-29 | 38 | 2018-08-20 | 2018-08-20 | 1d | 2018-08-20 | 2018-08-22 | 47d | 0d |  |
| 47 | 1.3.3.2 | Concretagem do fosso |  | 5d | 2018-08-30 | 2018-09-05 | 46 |  |  |  | 2018-08-23 | 2018-08-29 | 47d | 0d |  |
| 48 | 1.3.3.3 | Execução da infra enterrada |  | 3d | 2018-08-29 | 2018-08-31 | 46SS+2d | 2018-09-10 | 2018-09-12 | 3d | 2018-08-22 | 2018-08-24 | 50d | 3d |  |
| 49 | 1.3.3.4 | Preparação da área de piso |  | 4d | 2018-09-06 | 2018-09-12 | 46, 48, 47 | 2018-09-03 | 2018-09-06 | 4d | 2018-08-30 | 2018-09-04 | 47d | 0d |  |
| 50 | 1.3.3.5 | Concretagem da área de piso |  | 2d | 2018-09-13 | 2018-09-14 | 48, 49 | 2018-09-13 | 2018-09-14 | 2d | 2018-09-05 | 2018-09-06 | 47d | 0d |  |
| 51 | 1.3.4 | Assentamento das esquadrias |  | 10d | 2018-10-16 | 2018-10-29 | 50, 44 | 2018-09-17 | 2018-09-28 | 10d | 2018-09-10 | 2018-09-21 | 27d | 0d |  |
| 52 | 1.3.5 | Instalações |  | 8d | 2018-09-17 | 2018-09-26 | 50 | 2018-09-17 | 2018-09-26 | 8d | 2018-09-10 | 2018-09-19 | 28d |  |  |
| 53 | 1.3.6 | Pintura Externa |  | 5d | 2018-10-24 | 2018-10-30 | 50, 51SS+6d | 2018-09-25 | 2018-10-01 | 5d | 2018-09-18 | 2018-09-24 | 27d |  |  |

| ID | WBS | Task | Duration | Start | Finish | Predecessors | Baseline start | Baseline finish | Baseline duration | Baseline 1 start | Baseline 1 finish | Total slack | Free slack |
| --- | --- | --- | --- | --- | --- | --- | --- | --- | --- | --- | --- | --- | --- |
| 54 | 1.4 | **ESCRITÓRIO** | 50d | 2018-09-27 | 2018-12-11 |  | 2018-08-08 | 2018-10-18 | 50d | 2018-08-15 | 2018-10-26 | 0d |  |
| 55 | 1.4.1 | **ESTRUTURA** | 25d | 2018-09-27 | 2018-11-01 |  | 2018-08-08 | 2018-09-14 | 27d | 2018-08-15 | 2018-09-19 | 0d |  |
| 56 | 1.4.1.1 | **TÉRREO** | 8d | 2018-09-27 | 2018-10-08 |  | 2018-08-08 | 2018-08-21 | 10d | 2018-08-15 | 2018-08-24 | 0d |  |
| 57 | 1.4.1.1.1 | Execução das vigas | 5d | 2018-09-27 | 2018-10-03 | 4, 42FS+2d | 2018-08-08 | 2018-08-14 | 5d | 2018-08-15 | 2018-08-21 | 0d |  |
| 58 | 1.4.1.1.2 | Montagem do escoramento | 5d | 2018-09-27 | 2018-10-03 | 57SS | 2018-08-08 | 2018-08-16 | 7d | 2018-08-15 | 2018-08-21 | 0d |  |
| 59 | 1.4.1.1.3 | Montagem das lajes e concretagem | 3d | 2018-10-04 | 2018-10-08 | 58 | 2018-08-17 | 2018-08-21 | 3d | 2018-08-22 | 2018-08-24 | 0d |  |
| 60 | 1.4.1.2 | **1º PVTO** | 10d | 2018-10-10 | 2018-10-24 |  | 2018-08-23 | 2018-09-05 | 10d | 2018-08-28 | 2018-09-11 | 0d |  |
| 61 | 1.4.1.2.1 | Execução dos pilares | 3d | 2018-10-10 | 2018-10-15 | 59FS+1d | 2018-08-23 | 2018-08-27 | 3d | 2018-08-28 | 2018-08-30 | 0d |  |
| 62 | 1.4.1.2.2 | Execução das vigas | 3d | 2018-10-16 | 2018-10-18 | 61 | 2018-08-28 | 2018-08-30 | 3d | 2018-08-31 | 2018-09-04 | 0d |  |
| 63 | 1.4.1.2.3 | Montagem do escoramento | 4d | 2018-10-16 | 2018-10-19 | 62SS | 2018-08-28 | 2018-08-31 | 4d | 2018-08-31 | 2018-09-05 | 0d |  |
| 64 | 1.4.1.2.4 | Montagem das lajes e concretagem | 3d | 2018-10-22 | 2018-10-24 | 63 | 2018-09-03 | 2018-09-05 | 3d | 2018-09-06 | 2018-09-11 | 0d |  |
| 65 | 1.4.1.3 | **COBERTURA** | 5d | 2018-10-26 | 2018-11-01 |  | 2018-09-10 | 2018-09-14 | 5d | 2018-09-13 | 2018-09-19 | 25d |  |
| 66 | 1.4.1.3.1 | Estrutura da cobertura metálica | 2d | 2018-10-26 | 2018-10-29 | 64FS+1d | 2018-09-10 | 2018-09-11 | 2d | 2018-09-13 | 2018-09-14 | 25d | 0d |
| 67 | 1.4.1.3.2 | Montagem do telhamento metálico | 3d | 2018-10-30 | 2018-11-01 | 66 | 2018-09-12 | 2018-09-14 | 3d | 2018-09-17 | 2018-09-19 | 25d |  |
| 68 | 1.4.2 | **ACABAMENTOS** | 33d | 2018-10-23 | 2018-12-11 |  | 2018-09-20 | 2018-10-18 | 20d | 2018-09-10 | 2018-10-26 | 0d |  |
| 69 | 1.4.2.1 | **TÉRREO** | 20d | 2018-10-23 | 2018-11-21 |  | 2018-09-20 | 2018-10-16 | 18d | 2018-09-10 | 2018-10-04 | 7d |  |
| 70 | 1.4.2.1.1 | Infra enterrada | 2d | 2018-10-23 | 2018-10-24 | 59FS+14ed | 2018-09-20 | 2018-09-21 | 2d | 2018-09-10 | 2018-09-11 | 13d | 0d |
| 71 | 1.4.2.1.2 | Contrapiso | 2d | 2018-10-25 | 2018-10-26 | 70 | 2018-09-24 | 2018-09-25 | 2d | 2018-09-12 | 2018-09-13 | 13d | 2d |
| 72 | 1.4.2.1.3 | Assentamento da alvenaria estrutural | 5d | 2018-10-24 | 2018-10-30 | 59FS+15ed |  |  |  | 2018-09-10 | 2018-09-14 | 6d | 0d |
| 73 | 1.4.2.1.4 | Revestimentos de parede | 2d | 2018-10-31 | 2018-11-01 | 71, 72 | 2018-09-26 | 2018-09-27 | 2d | 2018-09-17 | 2018-09-18 | 13d | 0d |
| 74 | 1.4.2.1.5 | Elétrica/ Hidráulica | 2d | 2018-11-05 | 2018-11-06 | 73 | 2018-09-28 | 2018-10-01 | 2d | 2018-09-19 | 2018-09-20 | 13d | 0d |
| 75 | 1.4.2.1.6 | Acabamentos parede (revestimento + rejunte) | 2d | 2018-11-07 | 2018-11-08 | 74 | 2018-10-02 | 2018-10-03 | 2d | 2018-09-21 | 2018-09-24 | 13d | 0d |
| 76 | 1.4.2.1.7 | Acabamentos piso (revestimento + rejunte) | 2d | 2018-11-09 | 2018-11-12 | 75 | 2018-10-04 | 2018-10-05 | 2d | 2018-09-25 | 2018-09-26 | 13d | 0d |
| 77 | 1.4.2.1.8 | Assentamento das esquadrias | 2d | 2018-11-13 | 2018-11-14 | 76 | 2018-10-08 | 2018-10-09 | 2d | 2018-09-27 | 2018-09-28 | 13d | 0d |
| 78 | 1.4.2.1.9 | Assentamento de louças, bancadas e soleiras | 1d | 2018-11-16 | 2018-11-16 | 77 | 2018-10-10 | 2018-10-10 | 1d | 2018-10-01 | 2018-10-01 | 13d | 0d |
| 79 | 1.4.2.1.10 | Acabamentos elétricos e hidráulicos | 1d | 2018-11-19 | 2018-11-19 | 78 | 2018-10-11 | 2018-10-11 | 1d | 2018-10-02 | 2018-10-02 | 13d | 0d |
| 80 | 1.4.2.1.11 | Pintura | 2d | 2018-11-20 | 2018-11-21 | 79 | 2018-10-15 | 2018-10-16 | 2d | 2018-10-03 | 2018-10-04 | 13d |  |

| ID | WBS | Task | Duration | Start | Finish | Predecessors | Baseline start | Baseline finish | Baseline duration | Baseline 1 start | Baseline 1 finish | Total slack | Free slack |
| --- | --- | --- | --- | --- | --- | --- | --- | --- | --- | --- | --- | --- | --- |
| 81 | 1.4.2.2 | **1º PVTO** | 21d | 2018-11-09 | 2018-12-11 |  | 2018-09-26 | 2018-10-18 | 16d | 2018-09-27 | 2018-10-26 | 0d |  |
| 82 | 1.4.2.2.1 | Assentamento da alvenaria estrutural | 5d | 2018-11-09 | 2018-11-16 | 72, 64FS+15ed |  |  |  | 2018-09-27 | 2018-10-03 | 0d |  |
| 83 | 1.4.2.2.2 | Contrapiso | 2d | 2018-11-19 | 2018-11-20 | 71, 82 | 2018-09-26 | 2018-09-27 | 2d | 2018-10-04 | 2018-10-05 | 0d |  |
| 84 | 1.4.2.2.3 | Revestimentos de parede | 2d | 2018-11-21 | 2018-11-22 | 83 | 2018-09-28 | 2018-10-01 | 2d | 2018-10-08 | 2018-10-09 | 0d |  |
| 85 | 1.4.2.2.4 | Elétrica/ Hidráulica | 2d | 2018-11-23 | 2018-11-27 | 84 | 2018-10-02 | 2018-10-03 | 2d | 2018-10-10 | 2018-10-11 | 0d |  |
| 86 | 1.4.2.2.5 | Acabamentos parede (revestimento + rejunte) | 2d | 2018-11-28 | 2018-11-29 | 85 | 2018-10-04 | 2018-10-05 | 2d | 2018-10-15 | 2018-10-16 | 0d |  |
| 87 | 1.4.2.2.6 | Acabamentos piso (revestimento + rejunte) | 2d | 2018-11-30 | 2018-12-03 | 86 | 2018-10-08 | 2018-10-09 | 2d | 2018-10-17 | 2018-10-18 | 0d |  |
| 88 | 1.4.2.2.7 | Assentamento das esquadrias | 2d | 2018-12-04 | 2018-12-05 | 87 | 2018-10-10 | 2018-10-11 | 2d | 2018-10-19 | 2018-10-22 | 0d |  |
| 89 | 1.4.2.2.8 | Assentamento de louças, bancadas e soleiras | 1d | 2018-12-06 | 2018-12-06 | 88 | 2018-10-15 | 2018-10-15 | 1d | 2018-10-23 | 2018-10-23 | 0d |  |
| 90 | 1.4.2.2.9 | Acabamentos elétricos e hidráulicos | 1d | 2018-12-07 | 2018-12-07 | 89 | 2018-10-16 | 2018-10-16 | 1d | 2018-10-24 | 2018-10-24 | 0d |  |
| 91 | 1.4.2.2.10 | Pintura | 2d | 2018-12-10 | 2018-12-11 | 90 | 2018-10-17 | 2018-10-18 | 2d | 2018-10-25 | 2018-10-26 | 0d |  |
| 92 | 1.4.3 | **ESCADAS** | 26d | 2018-10-22 | 2018-11-29 |  | 2018-09-03 | 2018-09-19 | 12d | 2018-09-06 | 2018-10-16 | 8d |  |
| 93 | 1.4.3.1 | Fundação das escadas | 10d | 2018-10-22 | 2018-11-05 | 63 | 2018-09-03 | 2018-09-13 | 8d | 2018-09-06 | 2018-09-20 | 20d | 12d |
| 94 | 1.4.3.2 | Instalação da escada de acesso | 2d | 2018-11-23 | 2018-11-27 | 93, 84 | 2018-09-14 | 2018-09-17 | 2d | 2018-10-10 | 2018-10-11 | 8d | 0d |
| 95 | 1.4.3.3 | Instalação da escada marinheiro | 2d | 2018-11-28 | 2018-11-29 | 94, 84 | 2018-09-18 | 2018-09-19 | 2d | 2018-10-15 | 2018-10-16 | 8d |  |
| 96 | 1.5 | **PAVIMENTO DE ACESSO** | 76d | 2018-08-02 | 2018-11-21 |  | 2018-08-02 | 2018-10-19 | 55d | 2018-08-02 | 2018-11-01 | 13d |  |
| 97 | 1.5.1 | **ACESSO AO GALPÃO** | 30d | 2018-08-02 | 2018-09-13 |  | 2018-08-02 | 2018-09-04 | 24d | 2018-08-02 | 2018-08-31 | 37d |  |
| 98 | 1.5.1.1 | Marcação topográfica | 1d | 2018-08-02 | 2018-08-02 | 2SS+8d | 2018-08-02 | 2018-08-02 | 1d | 2018-08-02 | 2018-08-02 | 37d | 0d |
| 99 | 1.5.1.2 | Locação da área | 2d | 2018-08-03 | 2018-08-06 | 98 | 2018-08-03 | 2018-08-06 | 2d | 2018-08-03 | 2018-08-06 | 37d | 0d |
| 100 | 1.5.1.3 | Ajuste (corte/ aterro) | 4d | 2018-08-17 | 2018-08-22 | 99FS+8d | 2018-08-07 | 2018-08-10 | 4d | 2018-08-07 | 2018-08-10 | 37d | 0d |
| 101 | 1.5.1.4 | Execução de guias, sarjetas e canaletas | 4d | 2018-08-23 | 2018-08-28 | 100 | 2018-08-13 | 2018-08-16 | 4d | 2018-08-13 | 2018-08-16 | 37d | 0d |
| 102 | 1.5.1.5 | Execução da sub base (abertura de caixa, lançamento de rachão e travamento) | 5d | 2018-08-29 | 2018-09-04 | 100, 101 | 2018-08-17 | 2018-08-23 | 5d | 2018-08-17 | 2018-08-23 | 37d | 0d |
| 103 | 1.5.1.6 | Execução da base do pavimento em BGS | 5d | 2018-09-05 | 2018-09-12 | 102 | 2018-08-24 | 2018-08-30 | 5d | 2018-08-24 | 2018-08-30 | 49d | 0d |
| 104 | 1.5.1.7 | Lançamento de binder | 1d | 2018-09-13 | 2018-09-13 | 103 | 2018-09-04 | 2018-09-04 | 1d | 2018-08-31 | 2018-08-31 | 59d | 0d |
| 105 | 1.5.1.8 | Plantio de grama | 4d | 2018-09-10 | 2018-09-13 | 104FF | 2018-08-30 | 2018-09-04 | 4d | 2018-08-28 | 2018-08-31 | 59d |  |

| ID | WBS | Task | Duration | Start | Finish | Predecessors | Baseline start | Baseline finish | Baseline duration | Baseline 1 start | Baseline 1 finish | Total slack | Free slack | Constraint |
| --- | --- | --- | --- | --- | --- | --- | --- | --- | --- | --- | --- | --- | --- | --- |
| 106 | 1.5.2 | **PÁTIO DE MANOBRA - GALPÃO** | 56d | 2018-08-30 | 2018-11-21 |  | 2018-08-02 | 2018-09-27 | 40d | 2018-08-21 | 2018-10-17 | 13d |  |  |
| 107 | 1.5.2.1 | **PÁTIO** | 20d | 2018-08-30 | 2018-09-27 |  | 2018-08-02 | 2018-09-04 | 24d | 2018-08-21 | 2018-09-17 | 41d |  |  |
| 108 | 1.5.2.1.1 | Marcação topográfica | 2d | 2018-08-30 | 2018-09-03 | 109SF | 2018-08-02 | 2018-08-03 | 2d | 2018-08-21 | 2018-08-23 | 67d |  |  |
| 109 | 1.5.2.1.2 | Locação da área | 2d | 2018-09-03 | 2018-09-05 | 110SF | 2018-08-03 | 2018-08-06 | 2d | 2018-08-23 | 2018-08-27 | 65d | 0d |  |
| 110 | 1.5.2.1.3 | Ajuste (corte/aterro) | 2d | 2018-09-05 | 2018-09-06 | 38, 100, 39, 40, 102 | 2018-08-20 | 2018-08-21 | 2d | 2018-08-27 | 2018-08-28 | 37d | 0d |  |
| 111 | 1.5.2.1.4 | Execução da sub base (abertura de caixa, lançamento de rachão e travamento) | 5d | 2018-09-13 | 2018-09-19 | 110, 103 | 2018-08-22 | 2018-08-27 | 4d | 2018-08-31 | 2018-09-06 | 49d | 0d |  |
| 112 | 1.5.2.1.5 | Execução da base do pavimento em BGS | 5d | 2018-09-20 | 2018-09-26 | 111 | 2018-08-28 | 2018-09-03 | 5d | 2018-09-10 | 2018-09-14 | 49d | 0d |  |
| 113 | 1.5.2.1.6 | Lançamento de Binder | 1d | 2018-09-27 | 2018-09-27 | 112 | 2018-09-04 | 2018-09-04 | 1d | 2018-09-17 | 2018-09-17 | 49d |  |  |
| 114 | 1.5.2.2 | **CALÇADAS** | 25d | 2018-10-16 | 2018-11-21 |  | 2018-08-22 | 2018-09-27 | 26d | 2018-09-10 | 2018-10-17 | 12d |  |  |
| 115 | 1.5.2.2.1 | Execução da base da calçada | 3d | 2018-10-16 | 2018-10-18 | 110, 38, 44 | 2018-08-22 | 2018-08-24 | 3d | 2018-09-10 | 2018-09-12 | 12d | 0d |  |
| 116 | 1.5.2.2.2 | Execução de forma e armação | 5d | 2018-10-19 | 2018-10-25 | 115 | 2018-08-27 | 2018-08-31 | 5d | 2018-09-13 | 2018-09-19 | 12d | 0d |  |
| 117 | 1.5.2.2.3 | Concretagem | 1d | 2018-10-26 | 2018-10-26 | 116, 32 | 2018-09-03 | 2018-09-03 | 1d | 2018-09-20 | 2018-09-20 | 12d | 0d |  |
| 118 | 1.5.2.2.4 | Execução de pintura epóxi | 3d | 2018-11-19 | 2018-11-21 | 117FS+21ed, 50, 5 | 2018-09-25 | 2018-09-27 | 3d | 2018-10-15 | 2018-10-17 | 13d |  |  |
| 119 | 1.5.3 | **DRENAGEM** | 13d | 2018-08-28 | 2018-09-14 |  | 2018-08-02 | 2018-09-03 | 23d | 2018-08-06 | 2018-09-03 | 58d |  |  |
| 120 | 1.5.3.1 | Marcação | 1d | 2018-09-13 | 2018-09-13 | 2 | 2018-08-02 | 2018-08-02 | 1d | 2018-08-06 | 2018-08-06 | 59d |  |  |
| 121 | 1.5.3.2 | Escavação da área da tubulação | 2d | 2018-08-28 | 2018-08-29 | 100FS+3d | 2018-08-16 | 2018-08-17 | 2d | 2018-08-16 | 2018-08-17 | 58d | 0d |  |
| 122 | 1.5.3.3 | Execução do fundo (berço para tubulação) | 2d | 2018-08-30 | 2018-08-31 | 121 | 2018-08-20 | 2018-08-21 | 2d | 2018-08-20 | 2018-08-21 | 58d | 0d |  |
| 123 | 1.5.3.4 | Assentamento da tubulação | 2d | 2018-09-03 | 2018-09-04 | 122 | 2018-08-22 | 2018-08-23 | 2d | 2018-08-22 | 2018-08-23 | 58d | 0d |  |
| 124 | 1.5.3.5 | Lançamento de terra e compactação | 2d | 2018-09-05 | 2018-09-06 | 123 | 2018-08-24 | 2018-08-27 | 2d | 2018-08-24 | 2018-08-27 | 58d | 0d |  |
| 125 | 1.5.3.6 | Execução das caixas de passagem | 5d | 2018-09-10 | 2018-09-14 | 124 | 2018-08-28 | 2018-09-03 | 5d | 2018-08-28 | 2018-09-03 | 58d |  |  |
| 126 | 1.5.4 | Capeamento - Asfalto | 1d | 2018-11-01 | 2018-11-01 |  | 2018-10-19 | 2018-10-19 | 1d | 2018-11-01 | 2018-11-01 | 3d |  | start no earlier than 2018-11-01 |
| 127 | 1.6 | **SUBESTAÇÃO** | 46d | 2018-08-21 | 2018-10-25 |  | 2018-08-21 | 2018-10-19 | 42d | 2018-08-17 | 2018-10-23 | 30d |  |  |
| 128 | 1.6.1 | Fundação | 5d | 2018-08-21 | 2018-08-27 | 11SS+2d | 2018-08-21 | 2018-08-27 | 5d | 2018-08-17 | 2018-08-23 | 30d | 0d |  |
| 129 | 1.6.2 | Execução da alvenaria estrutural | 8d | 2018-08-28 | 2018-09-06 | 128 | 2018-08-28 | 2018-09-06 | 8d | 2018-08-24 | 2018-09-04 | 30d | 0d |  |
| 130 | 1.6.3 | Execução da laje de cobertura | 8d | 2018-09-10 | 2018-09-19 | 129 | 2018-09-10 | 2018-09-14 | 5d | 2018-09-05 | 2018-09-17 | 30d | 0d |  |
| 131 | 1.6.4 | Execução da infra enterrada | 2d | 2018-09-27 | 2018-09-28 | 130FS+7ed | 2018-09-24 | 2018-09-25 | 2d | 2018-09-25 | 2018-09-26 | 30d | 0d |  |
| 132 | 1.6.5 | Concretagem do piso | 2d | 2018-10-01 | 2018-10-02 | 131 | 2018-09-26 | 2018-09-27 | 2d | 2018-09-27 | 2018-09-28 | 30d | 0d |  |
| 133 | 1.6.6 | Execução da infra elétrica e iluminação | 3d | 2018-10-03 | 2018-10-05 | 132 | 2018-09-28 | 2018-10-02 | 3d | 2018-10-01 | 2018-10-03 | 30d | 0d |  |
| 134 | 1.6.7 | Instalação das esquadrias | 4d | 2018-10-08 | 2018-10-11 | 133 | 2018-10-03 | 2018-10-05 | 3d | 2018-10-04 | 2018-10-09 | 30d | 0d |  |
| 135 | 1.6.8 | Acabamentos e pintura | 9d | 2018-10-15 | 2018-10-25 | 134 | 2018-10-08 | 2018-10-19 | 9d | 2018-10-10 | 2018-10-23 | 30d |  |  |

| ID | WBS | Task | Duration | Start | Finish | Predecessors | Baseline start | Baseline finish | Baseline duration | Baseline 1 start | Baseline 1 finish | Total slack | Free slack |
| --- | --- | --- | --- | --- | --- | --- | --- | --- | --- | --- | --- | --- | --- |
| 136 | 1.7 | **ESCADA DE ACESSO** | 29d | 2018-09-26 | 2018-11-07 |  | 2018-09-06 | 2018-10-18 | 29d | 2018-09-19 | 2018-10-30 | 22d |  |
| 137 | 1.7.1 | Marcação topográfica | 1d | 2018-09-26 | 2018-09-26 | 15 | 2018-09-06 | 2018-09-06 | 1d | 2018-09-19 | 2018-09-19 | 22d | 0d |
| 138 | 1.7.2 | Escavação | 8d | 2018-09-27 | 2018-10-08 | 137 | 2018-09-10 | 2018-09-19 | 8d | 2018-09-20 | 2018-10-01 | 22d | 0d |
| 139 | 1.7.3 | Execução de forma | 10d | 2018-10-03 | 2018-10-17 | 138SS+4d | 2018-09-14 | 2018-09-27 | 10d | 2018-09-26 | 2018-10-09 | 22d | 0d |
| 140 | 1.7.4 | Execução de armação | 10d | 2018-10-05 | 2018-10-19 | 139SS+2d | 2018-09-18 | 2018-10-01 | 10d | 2018-09-28 | 2018-10-11 | 22d | 0d |
| 141 | 1.7.5 | Concretagem | 2d | 2018-10-22 | 2018-10-23 | 140 | 2018-10-02 | 2018-10-03 | 2d | 2018-10-15 | 2018-10-16 | 22d | 0d |
| 142 | 1.7.6 | Instalação do corrimão | 5d | 2018-10-24 | 2018-10-30 | 141 | 2018-10-04 | 2018-10-10 | 5d | 2018-10-17 | 2018-10-23 | 22d | 0d |
| 143 | 1.7.7 | Pintura e acabamentos | 5d | 2018-10-31 | 2018-11-07 | 142 | 2018-10-11 | 2018-10-18 | 5d | 2018-10-24 | 2018-10-30 | 22d |  |
| 144 | 1.8 | **SERVIÇOS FINAIS** | 4d | 2018-12-10 | 2018-12-13 |  | 2018-10-18 | 2018-10-23 | 4d | 2018-10-31 | 2018-11-06 | 0d |  |
| 145 | 1.8.1 | Limpeza da área | 2d | 2018-12-10 | 2018-12-11 | 146FF-2d | 2018-10-18 | 2018-10-19 | 2d | 2018-10-31 | 2018-11-01 | 2d |  |
| 146 | 1.8.2 | Desmobilização | 2d | 2018-12-12 | 2018-12-13 | 2, 5, 34, 54, 96, 127, 136 | 2018-10-22 | 2018-10-23 | 2d | 2018-11-05 | 2018-11-06 | 0d |  |
