# CRONOGRAMA FÍSICO - OBRA RESIDENCIAL

Schedule from MS Project, 2018-01-02 to 2018-07-30.

## Calendars

- Padrão: Mon-Fri 09:00-12:00, 13:00-18:00; Sat-Sun off.

## Schedule

| ID | WBS | Task | Type | Duration | Start | Finish | Predecessors | Total slack | Constraint |
| --- | --- | --- | --- | --- | --- | --- | --- | --- | --- |
| 1 | 1 | Aprovação dos projetos na prefeitura | milestone | 0d | 2018-01-02 | 2018-01-02 |  | 0d |  |
| 2 | 2 | Recebimento dos projetos e ESTUDOS E COMPATIBILIZADOS | milestone | 0d | 2018-01-02 | 2018-01-02 |  | 0d |  |
| 3 | 3 | MARCO - Início de obra | milestone | 0d | 2018-01-02 | 2018-01-02 | 1, 2 | 0d | start no earlier than 2018-01-02 |
| 4 | 4 | **CONSTRUÇÃO DE CASA (PRAZO DE OBRA: 8 MESES)** |  | 150d | 2018-01-02 | 2018-07-30 |  | 0d |  |
| 5 | 4.1 | **CONCESSONÁRIAS E APROVAÇÕES** |  | 10d | 2018-01-02 | 2018-01-15 |  | 140d |  |
| 6 | 4.1.1 | Instalação de oste de entrada (energia para a obra) - PROVISÓRIA |  | 10d | 2018-01-02 | 2018-01-15 | 3 | 140d |  |
| 7 | 4.1.2 | Instalação de cavalete de água (água para o canteiro de obra - será o definitivo) |  | 10d | 2018-01-02 | 2018-01-15 | 3 | 140d |  |
| 8 | 4.1.3 | Ligação do esgoto sanitário (esgoto para ligação do banheiro de obra - será o definitivo) |  | 10d | 2018-01-02 | 2018-01-15 | 3FF | 140d |  |
| 9 | 4.2 | **SERVIÇOS INICIAIS DE OBRA** |  | 8d | 2018-01-02 | 2018-01-11 |  | 0d |  |
| 10 | 4.2.1 | Limpeza do Terreno |  | 1d | 2018-01-02 | 2018-01-02 | 3 | 0d |  |
| 11 | 4.2.2 | Terraplenagem (corte/aterro) |  | 2d | 2018-01-03 | 2018-01-04 | 10 | 0d |  |
| 12 | 4.2.3 | Definição de Nível interno da casa |  | 1d | 2018-01-04 | 2018-01-04 | 11FF | 0d |  |
| 13 | 4.2.4 | Montagem do canteiro de obra |  | 2d | 2018-01-05 | 2018-01-08 | 11, 12 | 0d |  |
| 14 | 4.2.5 | Gabarito de Obra |  | 2d | 2018-01-08 | 2018-01-09 | 13SS+1d | 0d |  |
| 15 | 4.2.6 | Demarcação de fundação (fundações profundas ou fundações diretas, baldrames e alvenarias) |  | 2d | 2018-01-10 | 2018-01-11 | 14 | 0d |  |
| 16 | 4.3 | **FUNDAÇÃO** |  | 31d | 2018-01-12 | 2018-02-23 |  | 0d |  |
| 17 | 4.3.1 | **FUNDAÇÕES PROFUNDAS** |  | 10d | 2018-01-12 | 2018-01-25 |  | 132d |  |
| 18 | 4.3.1.1 | Execução das fundações profundas (STRAUSS OU BROCA ROTATIVO/MANUAL) |  | 10d | 2018-01-12 | 2018-01-25 | 15 | 132d |  |
| 19 | 4.3.2 | **FUNDAÇÃO RASA** |  | 31d | 2018-01-12 | 2018-02-23 |  | 0d |  |
| 20 | 4.3.2.1 | **SAPATAS CORRIDAS** |  | 15d | 2018-01-12 | 2018-02-01 |  | 0d |  |
| 21 | 4.3.2.1.1 | Escavação manual das sapatas |  | 8d | 2018-01-12 | 2018-01-23 | 15 | 0d |  |
| 22 | 4.3.2.1.2 | Acerto e compactação de fundo com socador + Lastro de brita 1 |  | 8d | 2018-01-17 | 2018-01-26 | 21SS+3d | 0d |  |
| 23 | 4.3.2.1.3 | Lona plástica |  | 1d | 2018-01-26 | 2018-01-26 | 22FF | 0d |  |
| 24 | 4.3.2.1.4 | Armação das sapatas corridas + colocação das formas laterais niveladas |  | 6d | 2018-01-24 | 2018-01-31 | 23FS-3d | 0d |  |
| 25 | 4.3.2.1.5 | Arranques dos Pilares |  | 2d | 2018-01-30 | 2018-01-31 | 24FF | 0d |  |
| 26 | 4.3.2.1.6 | Concreto (lançamento e adensamento) |  | 1d | 2018-02-01 | 2018-02-01 | 24, 25 | 0d |  |

| ID | WBS | Task | Type | Duration | Start | Finish | Predecessors | Total slack | Free slack |
| --- | --- | --- | --- | --- | --- | --- | --- | --- | --- |
| 27 | 4.3.2.2 | **EMBASAMENTO** |  | 15d | 2018-02-05 | 2018-02-23 |  | 0d |  |
| 28 | 4.3.2.2.1 | Alvenaria de embasamento |  | 1d | 2018-02-05 | 2018-02-05 | 26FS+1d | 0d |  |
| 29 | 4.3.2.2.2 | Instalação Hidráulica enterrada |  | 1d | 2018-02-06 | 2018-02-06 | 28 | 0d |  |
| 30 | 4.3.2.2.3 | Instalação Elétrica enterrada |  | 1d | 2018-02-06 | 2018-02-06 | 28 | 124d |  |
| 31 | 4.3.2.2.4 | Emboço face nas 3 faces da alvenaria |  | 2d | 2018-02-07 | 2018-02-08 | 28, 29 | 0d |  |
| 32 | 4.3.2.2.5 | Impermeabilização com argamassa |  | 1d | 2018-02-12 | 2018-02-12 | 31FS+1d | 0d |  |
| 33 | 4.3.2.2.6 | Tinta betuminosa |  | 1d | 2018-02-13 | 2018-02-13 | 32 | 0d |  |
| 34 | 4.3.2.2.7 | Reaterro interno da edificação + caixa de passagem de água pluvial |  | 8d | 2018-02-14 | 2018-02-23 | 32, 33 | 111d |  |
| 35 | 4.4 | **ALVENARIA E ESTRUTURA** |  | 58d | 2018-02-14 | 2018-05-04 |  | 0d |  |
| 36 | 4.4.1 | **ALVENARIA E ESTRUTURA PILARES** |  | 20d | 2018-02-14 | 2018-03-13 |  | 0d |  |
| 37 | 4.4.1.1 | Marcação da 1ª fiada |  | 2d | 2018-02-14 | 2018-02-15 | 33, 32 | 0d |  |
| 38 | 4.4.1.2 | Elevação da alvenaria até altura da verga |  | 8d | 2018-02-16 | 2018-02-27 | 37 | 0d |  |
| 39 | 4.4.1.3 | Concretagem dos pilares até a altura da verga (forma, armação e concretagem) |  | 8d | 2018-02-16 | 2018-02-27 | 38FF | 0d |  |
| 40 | 4.4.1.4 | Execução de vergas (forma, armação e concretagem) |  | 1d | 2018-02-28 | 2018-02-28 | 39, 38 | 0d |  |
| 41 | 4.4.1.5 | Elevação da alvenaria até altura da contraverga |  | 2d | 2018-03-01 | 2018-03-02 | 40, 39 | 0d |  |
| 42 | 4.4.1.6 | Concretagem dos pilares até a altura da contraverga |  | 1d | 2018-03-02 | 2018-03-02 | 41FF | 0d |  |
| 43 | 4.4.1.7 | Execução de contraverga (forma, armação e concretagem) |  | 1d | 2018-03-05 | 2018-03-05 | 42, 41 | 0d |  |
| 44 | 4.4.1.8 | Elevação da alvenaria até a altura de fundo da viga de respaldo |  | 6d | 2018-03-06 | 2018-03-13 | 43 | 0d |  |
| 45 | 4.4.2 | **ESTRUTURA VIGAS** |  | 5d | 2018-03-14 | 2018-03-20 |  | 0d |  |
| 46 | 4.4.2.1 | Armação das vigas |  | 2d | 2018-03-14 | 2018-03-15 | 44 | 0d |  |
| 47 | 4.4.2.2 | Forma lateral das vigas |  | 2d | 2018-03-15 | 2018-03-16 | 46SS+1d | 0d |  |
| 48 | 4.4.2.3 | Execução das passagens nas vigas (conduites elétrica, tubulações) |  | 2d | 2018-03-16 | 2018-03-19 | 47FS-1d | 0d |  |
| 49 | 4.4.2.4 | Concretagem (lançamento e adensamento) |  | 1d | 2018-03-20 | 2018-03-20 | 46, 47, 48 | 0d |  |
| 50 | 4.4.3 | **ESTRUTURA LAJES** |  | 13d | 2018-03-21 | 2018-04-06 |  | 0d |  |
| 51 | 4.4.3.1 | Fabricação e Escoramento das lajes |  | 3d | 2018-03-21 | 2018-03-23 | 49 | 0d |  |
| 52 | 4.4.3.2 | Montagem da laje |  | 5d | 2018-03-22 | 2018-03-28 | 51SS+1d, 49 | 0d |  |
| 53 | 4.4.3.3 | Instalações de Infra de Elétrica (execução de todos os conduítes e caixinhas) |  | 2d | 2018-03-28 | 2018-03-29 | 52FS-1d | 0d |  |
| 54 | 4.4.3.4 | Forma de fechamento lateral das lajes |  | 3d | 2018-03-29 | 2018-04-02 | 52 | 3d | 0d |
| 55 | 4.4.3.5 | Checagem das formas e escoramento |  | 1d | 2018-04-02 | 2018-04-02 | 54FF | 85d |  |
| 56 | 4.4.3.6 | Execução de vãos de passagens nas lajes (ex. locais com shaft, exaustão, etc) |  | 1d | 2018-03-30 | 2018-03-30 | 53 | 4d |  |
| 57 | 4.4.3.7 | Armação das lajes (malhas, negativos, etc.) |  | 5d | 2018-03-30 | 2018-04-05 | 53, 52 | 0d |  |
| 58 | 4.4.3.8 | Concretagem (lançamento e adensamento) |  | 1d | 2018-04-06 | 2018-04-06 | 57, 56, 53, 54 | 0d |  |
| 59 | 4.4.4 | RETIRA DAS ESCORAS - (EVENTO) | milestone | 0d | 2018-05-04 | 2018-05-04 | 58FS+28ed | 3d | 0d |

| ID | WBS | Task | Duration | Start | Finish | Predecessors | Total slack | Free slack |
| --- | --- | --- | --- | --- | --- | --- | --- | --- |
| 60 | 4.5 | **COBERTURA** | 28d | 2018-04-10 | 2018-05-17 |  | 11d |  |
| 61 | 4.5.1 | Execução da estrutura do telhamento | 10d | 2018-04-10 | 2018-04-23 | 58FS+3ed | 11d | 0d |
| 62 | 4.5.2 | Instalação das telhas do telhamento | 8d | 2018-04-24 | 2018-05-03 | 61, 73 | 11d | 0d |
| 63 | 4.5.3 | Execução das calhas | 3d | 2018-05-04 | 2018-05-08 | 62 | 40d | 0d |
| 64 | 4.5.4 | Instalação dos rufos | 2d | 2018-05-09 | 2018-05-10 | 63 | 40d | 0d |
| 65 | 4.5.5 | Execução das descidas de água pluvial | 5d | 2018-05-11 | 2018-05-17 | 64 | 40d |  |
| 66 | 4.6 | **INSTALAÇÕES ELÉTRICAS** | 73d | 2018-04-09 | 2018-07-18 |  | 3d |  |
| 67 | 4.6.1 | Marcação das paredes dos locais onde vão os conduítes e caixinhas e quadro de distribuição. Corte das paredes. Passagem dos conduites. Posicionar e nivelar as caixinhas. | 5d | 2018-04-09 | 2018-04-13 | 44, 58 | 5d |  |
| 68 | 4.6.2 | Distribuição de circuitos - enfiação | 3d | 2018-05-11 | 2018-05-16 | 67, 81SF | 47d | 44d |
| 69 | 4.6.3 | Montagem do Quadro de distribuição | 2d | 2018-07-17 | 2018-07-18 | 68, 70SS | 3d |  |
| 70 | 4.6.4 | Colocação dos acabamentos elétricos | 2d | 2018-07-17 | 2018-07-18 | 68, 93, 91 | 3d | 0d |
| 71 | 4.7 | **INSTALAÇÕES HIDRÁULICAS** | 76d | 2018-04-09 | 2018-07-23 |  | 0d |  |
| 72 | 4.7.1 | Marcação das paredes tubulações hidráulicas. Corte das paredes. Execução da tubulação hidráulica + interligação com a caixa dágua. | 10d | 2018-04-09 | 2018-04-20 | 44, 58 | 0d |  |
| 73 | 4.7.2 | Instalação e derivações da Caixa d'água | 5d | 2018-04-10 | 2018-04-16 | 61SS | 16d | 5d |
| 74 | 4.7.3 | Instalação de louças e pia da cozinha | 3d | 2018-07-17 | 2018-07-19 | 91, 72, 86 | 0d |  |
| 75 | 4.7.4 | Instalação de metais | 2d | 2018-07-20 | 2018-07-23 | 74, 94SS | 0d |  |
| 76 | 4.8 | **REVESTIMENTOS INTERNOS** | 56d | 2018-04-23 | 2018-07-09 |  | 0d |  |
| 77 | 4.8.1 | **REVESTIMENTOS DE PAREDES E TETO** | 40d | 2018-04-23 | 2018-06-15 |  | 0d |  |
| 78 | 4.8.1.1 | Chapisco + Emboço sarrafeado | 8d | 2018-04-23 | 2018-05-02 | 72, 67, 89 | 0d |  |
| 79 | 4.8.1.2 | Revestimento cerâmico (azulejo) | 6d | 2018-06-01 | 2018-06-08 | 78FS+21d | 0d |  |
| 80 | 4.8.1.3 | Rejuntamento | 2d | 2018-06-14 | 2018-06-15 | 79FS+3d | 24d |  |
| 81 | 4.8.1.4 | Gesso teto parede direto no bloco | 12d | 2018-05-16 | 2018-05-31 | 89, 67, 59FS+4ed, 84, 62 | 3d | 0d |
| 82 | 4.8.1.5 | Forro de gesso em placa (caso exista) e/ou moldura para gesso liso | 3d | 2018-06-01 | 2018-06-05 | 81 | 3d |  |
| 83 | 4.8.2 | **REVESTIMENTOS DE PISO** | 46d | 2018-05-07 | 2018-07-09 |  | 0d |  |
| 84 | 4.8.2.1 | Contrapiso | 7d | 2018-05-07 | 2018-05-15 | 59 | 3d | 0d |
| 85 | 4.8.2.2 | Piso cerâmico | 10d | 2018-06-11 | 2018-06-22 | 84FS+21ed, 81, 82, 79 | 0d |  |
| 86 | 4.8.2.3 | Rejuntamento | 3d | 2018-06-28 | 2018-07-02 | 85FS+3d | 0d |  |
| 87 | 4.8.2.4 | Assentamento de pedras (granitos, marmores - caso exista) | 5d | 2018-07-03 | 2018-07-09 | 86 | 0d |  |

| ID | WBS | Task | Duration | Start | Finish | Predecessors | Total slack | Free slack |
| --- | --- | --- | --- | --- | --- | --- | --- | --- |
| 88 | 4.9 | **ESQUADRIAS** | 71d | 2018-04-09 | 2018-07-16 |  | 0d |  |
| 89 | 4.9.1 | Instalação dos Contra marcos ou propria janela definitiva (caso existam) | 3d | 2018-04-09 | 2018-04-11 | 58, 44 | 7d |  |
| 90 | 4.9.2 | Instalação das Esquadrias de Aluminio (ou ferro) | 5d | 2018-07-02 | 2018-07-06 | 89, 93 | 6d |  |
| 91 | 4.9.3 | Instalação das portas internas e externas | 5d | 2018-07-10 | 2018-07-16 | 89, 93, 87, 90SS | 0d |  |
| 92 | 4.10 | **PINTURAS** | 22d | 2018-06-25 | 2018-07-24 |  | 4d |  |
| 93 | 4.10.1 | Aplicação de 1 demão de Selador e retoques no gesso | 5d | 2018-06-25 | 2018-06-29 | 81, 82, 85 | 6d | 0d |
| 94 | 4.10.2 | Aplicação Pintura Látex (2 a 3 demãos finais) | 3d | 2018-07-20 | 2018-07-24 | 93, 88, 76, 74 | 0d |  |
| 95 | 4.10.3 | Pintura de esquadrias de ferro | 2d | 2018-07-23 | 2018-07-24 | 94FF | 4d |  |
| 96 | 4.11 | **FACHADA** | 43d | 2018-05-04 | 2018-07-03 |  | 14d |  |
| 97 | 4.11.1 | Chapisco + Emboço paulista (desempenado) | 10d | 2018-05-04 | 2018-05-17 | 58, 89, 62 | 20d | 0d |
| 98 | 4.11.2 | Aplicação de 1 demão de Selador na Fachada | 2d | 2018-06-25 | 2018-06-26 | 97FS+28ed, 60, 93SS | 14d | 0d |
| 99 | 4.11.3 | Aplicação Pintura Látex (3 demãos) ou Textura (2 demão) | 5d | 2018-06-27 | 2018-07-03 | 98 | 14d |  |
| 100 | 4.12 | **ÁREAS EXTERNAS** | 15d | 2018-05-18 | 2018-06-07 |  | 37d |  |
| 101 | 4.12.1 | Acerto do terreno ao redor da casa + lastro de brita | 5d | 2018-05-18 | 2018-05-24 | 97 | 37d | 0d |
| 102 | 4.12.2 | Execução de base para estacionamento de automóveis | 10d | 2018-05-25 | 2018-06-07 | 101 | 37d | 0d |
| 103 | 4.12.3 | Execução de calçada externa, conforme Projeto da Prefeitura | 10d | 2018-05-25 | 2018-06-07 | 102SS | 37d |  |
| 104 | 4.13 | **SERVIÇOS FINAIS** | 5d | 2018-07-24 | 2018-07-30 |  | 0d |  |
| 105 | 4.13.1 | Limpeza geral | 2d | 2018-07-24 | 2018-07-25 | 76, 71, 66, 96 | 0d |  |
| 106 | 4.13.2 | Check list | 3d | 2018-07-26 | 2018-07-30 | 105 | 0d |  |
